Schedule from MS Project, 2003-02-20 to 2003-04-17.
office

## Calendars

- 标准: Mon-Fri 08:00-12:00, 13:00-17:00; Sat-Sun off. Exceptions (off unless hours are given): 2003-02-01 to 2003-04-30 08:00-12:00, 13:00-17:00.

## Schedule

| ID | WBS | Task | Duration | Start | Finish | Predecessors | Baseline start | Baseline finish | Baseline duration | Total slack | Free slack | Constraint |
| --- | --- | --- | --- | --- | --- | --- | --- | --- | --- | --- | --- | --- |
| 1 | 1 | **倚林佳园降水护坡工程** | 24d | 2003-02-20 08:00 | 2003-03-15 17:00 |  | 2003-02-20 08:00 | 2003-04-06 12:00 | 45.5d? | 6d |  |  |
| 2 | 1.1 | **施工准备** | 1d | 2003-02-20 08:00 | 2003-02-20 17:00 |  | 2003-02-20 08:00 | 2003-02-20 17:00 | 1d? | 38.5d |  |  |
| 3 | 1.1.1 | 临时水电 | 1d | 2003-02-20 08:00 | 2003-02-20 17:00 |  | 2003-02-20 08:00 | 2003-02-20 17:00 | 1d? | 4.5d | 0d | start no earlier than 2003-02-20 08:00 |
| 4 | 1.1.2 | 放井位线 | 0.5d | 2003-02-20 08:00 | 2003-02-20 12:00 | 3SS | 2003-02-20 08:00 | 2003-02-20 12:00 | 0.5d | 4.5d | 0d |  |
| 5 | 1.2 | **降水施工** | 23.5d | 2003-02-20 13:00 | 2003-03-15 17:00 | 4 | 2003-02-20 13:00 | 2003-03-22 17:00 | 30.5d? | 33d |  |  |
| 6 | 1.2.1 | 成孔 | 6d | 2003-02-20 13:00 | 2003-02-26 12:00 | 4SS | 2003-02-20 13:00 | 2003-02-24 12:00 | 4d | 50.5d | 0d |  |
| 7 | 1.2.2 | 洗井 | 1d | 2003-02-20 13:00 | 2003-02-21 12:00 | 6SS | 2003-02-20 13:00 | 2003-02-21 12:00 | 1d? | 56.5d | 0d |  |
| 8 | 1.2.3 | 布管 | 2d | 2003-02-25 08:00 | 2003-02-26 17:00 | 7 | 2003-02-21 13:00 | 2003-02-23 12:00 | 2d | 50d |  | finish no earlier than 2003-02-26 17:00 |
| 9 | 1.2.4 | 抽水 | 18d | 2003-02-26 08:00 | 2003-03-15 17:00 |  | 2003-02-25 08:00 | 2003-03-22 17:00 | 26d? | 33d |  | finish no earlier than 2003-03-15 17:00 |
| 10 | 1.3 | **土钉墙施工** | 17.5d | 2003-02-26 08:00 | 2003-03-15 12:00 |  | 2003-03-01 08:00 | 2003-04-06 12:00 | 36.5d? | 0d |  |  |
| 11 | 1.3.1 | **第一步土钉施工** | 2.5d | 2003-02-26 08:00 | 2003-02-28 12:00 |  | 2003-03-01 08:00 | 2003-03-03 12:00 | 2.5d? | 0d |  |  |
| 12 | 1.3.1.1 | 挖第一步土 | 1d | 2003-02-26 08:00 | 2003-02-26 17:00 |  | 2003-03-01 08:00 | 2003-03-01 17:00 | 1d? | 0d |  | start no earlier than 2003-02-26 08:00 |
| 13 | 1.3.1.2 | 土钉成孔 | 0.5d | 2003-02-27 08:00 | 2003-02-27 12:00 | 12 | 2003-03-02 08:00 | 2003-03-02 12:00 | 0.5d? | 33.5d | 0d |  |
| 14 | 1.3.1.3 | 土钉注浆、编钢筋网 | 0.5d | 2003-02-27 13:00 | 2003-02-27 17:00 | 13 | 2003-03-02 13:00 | 2003-03-02 17:00 | 0.5d | 33.5d | 0d |  |
| 15 | 1.3.1.4 | 喷射面层砼 | 0.5d | 2003-02-28 08:00 | 2003-02-28 12:00 | 14 | 2003-03-03 08:00 | 2003-03-03 12:00 | 0.5d | 33.5d |  |  |
| 16 | 1.3.2 | **第二步土钉施工** | 2.5d | 2003-02-28 13:00 | 2003-03-02 17:00 | 11 | 2003-03-05 13:00 | 2003-03-07 17:00 | 2.5d? | 33.5d | 0d |  |
| 17 | 1.3.2.1 | 挖第二步土 | 1d | 2003-02-28 13:00 | 2003-03-01 12:00 |  | 2003-03-05 13:00 | 2003-03-06 12:00 | 1d? | 33.5d | 0d |  |
| 18 | 1.3.2.2 | 土钉成孔 | 0.5d | 2003-03-01 13:00 | 2003-03-01 17:00 | 17 | 2003-03-06 13:00 | 2003-03-06 17:00 | 0.5d? | 33.5d | 0d |  |
| 19 | 1.3.2.3 | 土钉注浆、编钢筋网 | 0.5d | 2003-03-02 08:00 | 2003-03-02 12:00 | 18 | 2003-03-07 08:00 | 2003-03-07 12:00 | 0.5d | 33.5d | 0d |  |
| 20 | 1.3.2.4 | 喷射面层砼 | 0.5d | 2003-03-02 13:00 | 2003-03-02 17:00 | 19 | 2003-03-07 13:00 | 2003-03-07 17:00 | 0.5d | 33.5d |  |  |
| 21 | 1.3.3 | **第三步土钉施工** | 2.5d | 2003-03-03 08:00 | 2003-03-05 12:00 | 16 | 2003-03-10 08:00 | 2003-03-12 12:00 | 2.5d? | 33.5d | 0d |  |
| 22 | 1.3.3.1 | 挖第三步土 | 1d | 2003-03-03 08:00 | 2003-03-03 17:00 |  | 2003-03-10 08:00 | 2003-03-10 17:00 | 1d? | 33.5d | 0d |  |
| 23 | 1.3.3.2 | 土钉成孔 | 0.5d | 2003-03-04 08:00 | 2003-03-04 12:00 | 22 | 2003-03-11 08:00 | 2003-03-11 12:00 | 0.5d? | 33.5d | 0d |  |
| 24 | 1.3.3.3 | 土钉注浆、编钢筋网 | 0.5d | 2003-03-04 13:00 | 2003-03-04 17:00 | 23 | 2003-03-11 13:00 | 2003-03-11 17:00 | 0.5d | 33.5d | 0d |  |
| 25 | 1.3.3.4 | 喷射面层砼 | 0.5d | 2003-03-05 08:00 | 2003-03-05 12:00 | 24 | 2003-03-12 08:00 | 2003-03-12 12:00 | 0.5d | 33.5d |  |  |

| ID | WBS | Task | Duration | Start | Finish | Predecessors | Baseline start | Baseline finish | Baseline duration | Total slack | Free slack | Constraint |
| --- | --- | --- | --- | --- | --- | --- | --- | --- | --- | --- | --- | --- |
| 26 | 1.3.4 | **第四步土钉施工** | 2.5d | 2003-03-05 13:00 | 2003-03-07 17:00 | 21 | 2003-03-14 13:00 | 2003-03-16 17:00 | 2.5d? | 33.5d | 0d |  |
| 27 | 1.3.4.1 | 挖第四步土 | 1d | 2003-03-05 13:00 | 2003-03-06 12:00 |  | 2003-03-14 13:00 | 2003-03-15 12:00 | 1d? | 33.5d | 0d |  |
| 28 | 1.3.4.2 | 土钉成孔 | 0.5d | 2003-03-06 13:00 | 2003-03-06 17:00 | 27 | 2003-03-15 13:00 | 2003-03-15 17:00 | 0.5d? | 33.5d | 0d |  |
| 29 | 1.3.4.3 | 土钉注浆、编钢筋网 | 0.5d | 2003-03-07 08:00 | 2003-03-07 12:00 | 28 | 2003-03-16 08:00 | 2003-03-16 12:00 | 0.5d | 33.5d | 0d |  |
| 30 | 1.3.4.4 | 喷射面层砼 | 0.5d | 2003-03-07 13:00 | 2003-03-07 17:00 | 29 | 2003-03-16 13:00 | 2003-03-16 17:00 | 0.5d | 33.5d |  |  |
| 31 | 1.3.5 | **第五步土钉施工** | 2.5d | 2003-03-08 08:00 | 2003-03-10 12:00 | 26 | 2003-03-19 08:00 | 2003-03-21 12:00 | 2.5d? | 33.5d | 0d |  |
| 32 | 1.3.5.1 | 挖第五步土 | 1d | 2003-03-08 08:00 | 2003-03-08 17:00 |  | 2003-03-19 08:00 | 2003-03-19 17:00 | 1d? | 33.5d | 0d |  |
| 33 | 1.3.5.2 | 土钉成孔 | 0.5d | 2003-03-09 08:00 | 2003-03-09 12:00 | 32 | 2003-03-20 08:00 | 2003-03-20 12:00 | 0.5d? | 33.5d | 0d |  |
| 34 | 1.3.5.3 | 土钉注浆、编钢筋网 | 0.5d | 2003-03-09 13:00 | 2003-03-09 17:00 | 33 | 2003-03-20 13:00 | 2003-03-20 17:00 | 0.5d | 33.5d | 0d |  |
| 35 | 1.3.5.4 | 喷射面层砼 | 0.5d | 2003-03-10 08:00 | 2003-03-10 12:00 | 34 | 2003-03-21 08:00 | 2003-03-21 12:00 | 0.5d | 33.5d |  |  |
| 36 | 1.3.6 | **第六步土钉施工** | 2.5d | 2003-03-10 13:00 | 2003-03-12 17:00 | 31 | 2003-03-23 13:00 | 2003-03-25 17:00 | 2.5d? | 33.5d | 0d |  |
| 37 | 1.3.6.1 | 挖第六步土 | 1d | 2003-03-10 13:00 | 2003-03-11 12:00 |  | 2003-03-23 13:00 | 2003-03-24 12:00 | 1d? | 33.5d | 0d |  |
| 38 | 1.3.6.2 | 土钉成孔 | 0.5d | 2003-03-11 13:00 | 2003-03-11 17:00 | 37 | 2003-03-24 13:00 | 2003-03-24 17:00 | 0.5d? | 33.5d | 0d |  |
| 39 | 1.3.6.3 | 土钉注浆、编钢筋网 | 0.5d | 2003-03-12 08:00 | 2003-03-12 12:00 | 38 | 2003-03-25 08:00 | 2003-03-25 12:00 | 0.5d | 33.5d | 0d |  |
| 40 | 1.3.6.4 | 喷射面层砼 | 0.5d | 2003-03-12 13:00 | 2003-03-12 17:00 | 39 | 2003-03-25 13:00 | 2003-03-25 17:00 | 0.5d | 33.5d |  |  |
| 41 | 1.3.7 | **第七步土钉施工** | 2.5d | 2003-03-13 08:00 | 2003-03-15 12:00 | 36 | 2003-03-28 08:00 | 2003-03-30 12:00 | 2.5d? | 33.5d |  |  |
| 42 | 1.3.7.1 | 挖第七步土 | 1d | 2003-03-13 08:00 | 2003-03-13 17:00 |  | 2003-03-28 08:00 | 2003-03-28 17:00 | 1d? | 33.5d | 0d |  |
| 43 | 1.3.7.2 | 土钉成孔 | 0.5d | 2003-03-14 08:00 | 2003-03-14 12:00 | 42 | 2003-03-29 08:00 | 2003-03-29 12:00 | 0.5d? | 33.5d | 0d |  |
| 44 | 1.3.7.3 | 土钉注浆、编钢筋网 | 0.5d | 2003-03-14 13:00 | 2003-03-14 17:00 | 43 | 2003-03-29 13:00 | 2003-03-29 17:00 | 0.5d | 33.5d | 0d |  |
| 45 | 1.3.7.4 | 喷射面层砼 | 0.5d | 2003-03-15 08:00 | 2003-03-15 12:00 | 44 | 2003-03-30 08:00 | 2003-03-30 12:00 | 0.5d | 33.5d |  |  |
| 46 | 2 | 位移观测 | 50d | 2003-02-27 08:00 | 2003-04-17 17:00 | 12 | 2003-04-05 13:00 | 2003-04-06 12:00 | 1d? | 0d |  | finish no earlier than 2003-03-15 17:00 |
